# DeVasconcelosMartins_Evelyn_TFM_2017_02de2

Schedule from MS Project, 2018-05-01 to 2019-08-06, A marks actual dates.

## Calendars

- Estándar: Mon-Fri 09:00-13:00, 15:00-19:00; Sat-Sun off.

## Resources

| Resource |
| --- |
| DIRECTOR DEL PROYECTO |
| DIRECTOR DE INGENIERIA |
| JEFE SALA TÉCNICA |
| AUXILIAR 1 |
| AUXILIAR SALA T 2 |
| AUXILIAR 3 |
| AUXILIAR 4 |
| DIRECTOR DE PRODUCCION |
| JEFE PLANTA |
| JEFE ENSAMBLAJE |
| JEFE LOGÍSTICA |
| DIRECTOR SMS |
| JEFE SMS PLANTA |
| JEFE SMS OBRA |
| DIRECTOR ADMINISTRATIVO |
| JEFE RRHH |
| JEFE COMPRAS |
| ADMIN OBRA |
| CONTROLADOR DOCUMENTOS |
| DIRECTOR DE CONTRATOS |
| OPERARIO 1 |
| MONTADOR 3 |
| OPERARIO GRUA 1 |
| ALMACENISTA 3 |
| AUXILIAR MAQUINARIAS 1 |
| ALMACENISTA 2 |
| ALMACENISTA 1 |
| AUXILIAR MAQUINARIAS 3 |
| AUXILIAR MAQUINARIAS 2 |
| OPERARIO 7 |
| OPERARIO 6 |
| OPERARIO 2 |
| OPERARIO GRUA 3 |
| OPERARIO GRUA 2 |
| OPERARIO 3 |
| OPERARIO 2 |
| OPERARIO 1 |
| CHOFER 3 |
| CHOFER 2 |
| CHOFER 1 |
| CHOFER 4 |
| CHOFER 5 |
| CHOFER 6 |
| AUXILIAR MAQUINARIAS 4 |
| MECANICO 4 |
| MECANICO 3 |
| MECANICO 2 |
| MECANICO 1 |
| OPERARIO 5 |
| OPERARIO 4 |
| OPERARIO 3 |
| SOLDADOR 2 |
| SOLDADOR 1 |
| OPERARIO 8 |
| AYUDANTE 3 |
| CAPORAL 1 |
| SOLDADOR 7 |
| SOLDADOR 6 |
| SOLDADOR 5 |
| SOLDADOR 3 |
| SOLDADOR 4 |
| AYUDANTE 2 |
| AYUDANTE 1 |
| CAPORAL 2 |
| AUXILIAR 2 |
| AUXILIAR 1 |
| CAPORAL 3 |
| MONTADOR 2 |
| MONTADOR1 |
| MAESTRO OBRA |
| MONTADOR 4 |
| AYUDANTE 1 |
| ÁYUDANTE 3 |
| AYUDANTE 2 |
| AUXILIAR SALA T 1 |
| ALMACENISTA 1 |
| AYUDANTE 4 |
| DIRECTOR DE CALIDAD |
| AUXILIAR CALIDAD 1 |
| AUXILIAR CALIDAD 2 |

## Schedule

| ID | WBS | Task | Type | Duration | Start | Finish | Predecessors | Complete | Total slack | Free slack | Resources | Work |
| --- | --- | --- | --- | --- | --- | --- | --- | --- | --- | --- | --- | --- |
| 1 | 1 | CALENDARIO DE HITOS | milestone | 0d | 2018-05-01 | 2018-05-01 |  |  | 331d |  |  |  |
| 2 | 2 | FIRMA ACTA CONSTITUCION | milestone | 0d | 2018-05-01 A | 2018-05-01 A |  | 100% |  |  |  |  |
| 3 | 3 | APROBACIÓN DE DISEÑO DE ESTRUCTURA | milestone | 0d | 2018-06-19 | 2018-06-19 | 17SF |  | 296d |  |  |  |
| 4 | 4 | FABRICACION DE LA ESTRUCTURA: PERNOS, VIGAS, COLUMNAS, SOPORTES. | milestone | 0d | 2019-01-17 | 2019-01-17 | 15 |  | 144d | 0d |  |  |
| 5 | 5 | ACTA DE ENTREGA DE LA ESTRUCTURA EN OBRA | milestone | 0d | 2019-03-18 | 2019-03-18 | 55 |  | 101d |  |  |  |
| 6 | 6 | INICIO DE ENSAMBLAJE DE LA ESTRUCTURA | milestone | 0d | 2019-01-17 | 2019-01-17 | 82SS |  | 144d |  |  |  |
| 7 | 7 | ENTREGA Y LIBERACION DE OBRA | milestone | 0d | 2019-07-16 | 2019-07-16 | 122 |  | 0d |  |  |  |
| 8 | 8 | FIRMA ACTA DE CIERRE | milestone | 0d | 2019-08-06 | 2019-08-06 | 7, 13 |  | 0d |  |  |  |
| 9 | 9 | HITOS DE PAGO | milestone | 0d | 2018-05-01 | 2018-05-01 |  |  | 331d |  |  |  |
| 10 | 10 | INICIAL 20% | milestone | 0d | 2018-05-01 | 2018-05-01 | 2 |  | 331d |  |  |  |
| 11 | 11 | LIQUIDACION DE FABRICACION | milestone | 0d | 2019-01-17 | 2019-01-17 | 4 |  | 144d |  |  |  |
| 12 | 12 | LIQUIDACION DE TRANSPORTE | milestone | 0d | 2019-01-17 | 2019-01-17 | 4 |  | 144d |  |  |  |
| 13 | 13 | LIQUIDACION DE ENSAMBLAJE | milestone | 0d | 2019-08-06 | 2019-08-06 | 7SF+15d |  | 0d |  |  |  |
| 14 | 14 | **FABRICACION, TRANSPORTE Y ENSAMBLAJE DE ESTRUCTURA METÁLICA HOSPITAL DE GUANTA** |  | 313d | 2018-05-15 | 2019-07-25 |  |  | 8d |  | DIRECTOR ADMINISTRATIVO; CONTROLADOR DOCUMENTOS; DIRECTOR DE CONTRATOS; DIRECTOR DEL PROYECTO; JEFE RRHH; JEFE COMPRAS; AUXILIAR CALIDAD 1; AUXILIAR CALIDAD 2; DIRECTOR DE CALIDAD | 25656h |
| 15 | 14.1 | **DISEÑO Y FABRICACION** |  | 177d | 2018-05-15 | 2019-01-17 |  |  | 37d | 0d |  | 3120h |
| 16 | 14.1.1 | Diseño final de Estructura |  | 25d | 2018-05-15 | 2018-06-18 | 2SS+10d |  | 37d | 0d | JEFE SALA TÉCNICA; AUXILIAR SALA T 1; AUXILIAR SALA T 2 | 600h |
| 17 | 14.1.2 | Elaboracion de Planos de Taller |  | 30d | 2018-06-19 | 2018-07-30 | 16 |  | 37d | 0d | JEFE SALA TÉCNICA; AUXILIAR SALA T 1; AUXILIAR SALA T 2 | 720h |
| 18 | 14.1.3 | Adquisicion de Pernos y Tornillos |  | 25d | 2018-07-31 | 2018-09-03 | 16SS |  | 55d | 0d | JEFE SALA TÉCNICA; AUXILIAR SALA T 1; AUXILIAR SALA T 2 | 600h |
| 19 | 14.1.4 | Elaboracion de Planos de Ensamblaje |  | 30d | 2018-12-06 | 2019-01-17 | 82SF |  | 144d |  | JEFE SALA TÉCNICA; AUXILIAR SALA T 1; AUXILIAR SALA T 2 | 720h |
| 20 | 14.1.5 | **Elaboración Plantillaje** |  | 30d | 2018-07-31 | 2018-09-10 |  |  | 37d |  |  | 480h |
| 21 | 14.1.5.1 | Columnas |  | 5d | 2018-07-31 | 2018-08-06 | 17 |  | 37d | 0d | AUXILIAR 1; ALMACENISTA 1 | 80h |
| 22 | 14.1.5.2 | Vigas de Carga |  | 10d | 2018-08-07 | 2018-08-20 | 21 |  | 37d | 0d | AUXILIAR 1; ALMACENISTA 1 | 160h |
| 23 | 14.1.5.3 | Vigas Auxiliares |  | 5d | 2018-08-21 | 2018-08-27 | 22 |  | 37d | 0d | AUXILIAR 1; ALMACENISTA 1 | 80h |
| 24 | 14.1.5.4 | Soportes y Planchas |  | 10d | 2018-08-28 | 2018-09-10 | 23 |  | 69d | 0d | AUXILIAR 1; ALMACENISTA 1 | 160h |

| ID | WBS | Task | Duration | Start | Finish | Predecessors | Total slack | Free slack |
| --- | --- | --- | --- | --- | --- | --- | --- | --- |
| 25 | 14.1.6 | **Preparacion, Enderezado y Conformación** | 30d | 2018-08-07 | 2018-09-17 |  | 46d |  |
| 26 | 14.1.6.1 | Columnas | 18d | 2018-08-07 | 2018-08-30 | 21 | 46d | 0d |
| 27 | 14.1.6.2 | Vigas de Carga | 20d | 2018-08-21 | 2018-09-17 | 22 | 39d | 0d |
| 28 | 14.1.6.3 | Vigas Auxiliares | 12d | 2018-08-28 | 2018-09-12 | 23 | 37d | 0d |
| 29 | 14.1.6.4 | Soportes y Planchas | 5d | 2018-09-11 | 2018-09-17 | 24 | 69d | 0d |
| 30 | 14.1.7 | **Marcado de Ejecucion** | 29d | 2018-08-31 | 2018-10-10 |  | 46d |  |
| 31 | 14.1.7.1 | Columnas | 5d | 2018-08-31 | 2018-09-06 | 26 | 46d | 0d |
| 32 | 14.1.7.2 | Vigas de Carga | 12d | 2018-09-18 | 2018-10-03 | 27 | 39d | 0d |
| 33 | 14.1.7.3 | Vigas Auxiliares | 20d | 2018-09-13 | 2018-10-10 | 28 | 37d | 0d |
| 34 | 14.1.7.4 | Soportes y Planchas | 12d | 2018-09-18 | 2018-10-03 | 29 | 69d | 0d |
| 35 | 14.1.8 | **Cortes y perforaciones** | 39d | 2018-09-07 | 2018-10-31 |  | 46d |  |
| 36 | 14.1.8.1 | Columnas | 15d | 2018-09-07 | 2018-09-27 | 31 | 46d | 0d |
| 37 | 14.1.8.2 | Vigas de Carga | 15d | 2018-10-04 | 2018-10-24 | 32 | 39d | 0d |
| 38 | 14.1.8.3 | Vigas Auxiliares | 15d | 2018-10-11 | 2018-10-31 | 33 | 37d | 0d |
| 39 | 14.1.8.4 | Soportes y Planchas | 8d | 2018-10-04 | 2018-10-15 | 34 | 69d | 0d |
| 40 | 14.1.9 | **Armado** | 39d | 2018-09-28 | 2018-11-21 |  | 46d |  |
| 41 | 14.1.9.1 | Columnas | 25d | 2018-09-28 | 2018-11-01 | 36 | 46d | 0d |
| 42 | 14.1.9.2 | Vigas de Carga | 18d | 2018-10-25 | 2018-11-19 | 37 | 39d | 0d |
| 43 | 14.1.9.3 | Vigas Auxiliares | 15d | 2018-11-01 | 2018-11-21 | 38 | 37d | 0d |
| 44 | 14.1.9.4 | Soportes y Planchas | 5d | 2018-10-16 | 2018-10-22 | 39 | 69d | 0d |
| 45 | 14.1.10 | **Limpieza y Galvanizado** | 30d | 2018-10-23 | 2018-12-03 |  | 42d |  |
| 46 | 14.1.10.1 | Columnas | 13d | 2018-11-02 | 2018-11-20 | 41 | 46d | 0d |
| 47 | 14.1.10.2 | Vigas de Carga | 9d | 2018-11-20 | 2018-11-30 | 42 | 39d | 0d |
| 48 | 14.1.10.3 | Vigas Auxiliares | 8d | 2018-11-22 | 2018-12-03 | 43 | 37d | 0d |
| 49 | 14.1.10.4 | Soportes y Planchas | 3d | 2018-10-23 | 2018-10-25 | 44 | 69d | 0d |

| ID | WBS | Task | Duration | Start | Finish | Predecessors | Total slack | Free slack |
| --- | --- | --- | --- | --- | --- | --- | --- | --- |
| 50 | 14.1.11 | **Codificación** | 37d | 2018-10-26 | 2018-12-17 |  | 37d | 0d |
| 51 | 14.1.11.1 | Columnas | 10d | 2018-11-21 | 2018-12-04 | 46 | 46d | 26d |
| 52 | 14.1.11.2 | Vigas de Carga | 9d | 2018-12-03 | 2018-12-13 | 47 | 39d | 18d |
| 53 | 14.1.11.3 | Vigas Auxiliares | 10d | 2018-12-04 | 2018-12-17 | 48 | 37d | 17d |
| 54 | 14.1.11.4 | Soportes y Planchas | 5d | 2018-10-26 | 2018-11-01 | 49 | 69d | 0d |
| 55 | 14.2 | **TRANSPORTE Y LOGÍSTICA** | 92d | 2018-11-09 | 2019-03-18 |  | 64d | 0d |
| 56 | 14.2.1 | Revisión de Vehiculos | 10d | 2018-12-18 | 2018-12-31 | 50 | 37d | 0d |
| 57 | 14.2.2 | Tornillería y Pernos | 7d | 2018-11-27 | 2018-12-05 | 18FS+60d | 55d | 18d |
| 58 | 14.2.3 | Soportes y Planchas | 7d | 2018-11-09 | 2018-11-19 | 54FS+5d | 186d |  |
| 59 | 14.2.4 | Oficinas | 5d | 2019-01-24 | 2019-01-30 | 82SF+10d | 134d |  |
| 60 | 14.2.5 | Gruas | 20d | 2019-01-10 | 2019-02-06 | 82SF+15d | 129d |  |
| 61 | 14.2.6 | Herramientas y Equipos | 15d | 2019-01-10 | 2019-01-30 | 82SF+10d | 134d |  |
| 62 | 14.2.7 | **MÓDULO 3** | 12d | 2019-01-01 | 2019-01-16 | 56 | 37d | 0d |
| 63 | 14.2.7.1 | Traslado de Columnas | 12d | 2019-01-01 | 2019-01-16 | 51SS+3d, 57 | 37d | 3d |
| 64 | 14.2.7.2 | Traslado de Vigas Principales | 7d | 2019-01-01 | 2019-01-09 | 52SS+3d | 42d |  |
| 65 | 14.2.7.3 | Traslado de Correas | 7d | 2019-01-01 | 2019-01-09 | 53SS+3d | 42d |  |
| 66 | 14.2.8 | **MÓDULO 4** | 12d | 2019-01-17 | 2019-02-01 | 56 | 37d | 0d |
| 67 | 14.2.8.1 | Traslado de Columnas | 12d | 2019-01-17 | 2019-02-01 | 51, 62 | 37d |  |
| 68 | 14.2.8.2 | Traslado de Vigas Principales | 7d | 2019-01-17 | 2019-01-25 | 52, 62 | 42d |  |
| 69 | 14.2.8.3 | Traslado de Correas | 7d | 2019-01-17 | 2019-01-25 | 53, 62 | 42d |  |
| 70 | 14.2.9 | **MÓDULO 5** | 7d | 2019-02-04 | 2019-02-12 | 56 | 37d | 0d |
| 71 | 14.2.9.1 | Traslado de Columnas | 7d | 2019-02-04 | 2019-02-12 | 51, 66 | 37d |  |
| 72 | 14.2.9.2 | Traslado de Vigas Principales | 7d | 2019-02-04 | 2019-02-12 | 52, 66 | 37d |  |
| 73 | 14.2.9.3 | Traslado de Correas | 4d | 2019-02-04 | 2019-02-07 | 53, 66 | 40d |  |

| ID | WBS | Task | Duration | Start | Finish | Predecessors | Total slack | Free slack |
| --- | --- | --- | --- | --- | --- | --- | --- | --- |
| 74 | 14.2.10 | **MÓDULO 1** | 12d | 2019-02-13 | 2019-02-28 | 56 | 37d | 0d |
| 75 | 14.2.10.1 | Traslado de Columnas | 12d | 2019-02-13 | 2019-02-28 | 70, 51 | 37d |  |
| 76 | 14.2.10.2 | Traslado de Vigas Principales | 7d | 2019-02-13 | 2019-02-21 | 70, 52 | 42d |  |
| 77 | 14.2.10.3 | Traslado de Correas | 7d | 2019-02-13 | 2019-02-21 | 70, 52 | 42d |  |
| 78 | 14.2.11 | **MÓDULO 2** | 12d | 2019-03-01 | 2019-03-18 | 56 | 45d |  |
| 79 | 14.2.11.1 | Traslado de Columnas | 12d | 2019-03-01 | 2019-03-18 | 74, 51 | 45d |  |
| 80 | 14.2.11.2 | Traslado de Vigas Principales | 7d | 2019-03-01 | 2019-03-11 | 74, 52 | 50d |  |
| 81 | 14.2.11.3 | Traslado de Correas | 7d | 2019-03-01 | 2019-03-11 | 74, 53 | 50d |  |
| 82 | 14.3 | **ENSAMBLAJE** | 128d | 2019-01-17 | 2019-07-15 |  | 0d |  |
| 83 | 14.3.1 | **MODULO 3** | 40d | 2019-01-17 | 2019-03-13 | 62 | 58d |  |
| 84 | 14.3.1.1 | Nivelación de pernos de anclaje | 3d | 2019-01-17 | 2019-01-21 | 57 | 58d | 0d |
| 85 | 14.3.1.2 | Izado y Colocación de columnas | 5d | 2019-01-22 | 2019-01-28 | 84, 63 | 58d | 0d |
| 86 | 14.3.1.3 | Ensamblaje Vigas Carga | 15d | 2019-01-24 | 2019-02-13 | 85SS+2d | 58d | 0d |
| 87 | 14.3.1.4 | Ensamblaje Vigas Auxiliares | 20d | 2019-01-31 | 2019-02-27 | 86SS+5d | 58d | 0d |
| 88 | 14.3.1.5 | Arriostramientos, Soportes | 7d | 2019-02-05 | 2019-02-13 | 86SS+8d | 108d |  |
| 89 | 14.3.1.6 | Ajustes | 10d | 2019-02-28 | 2019-03-13 | 87 | 88d |  |
| 90 | 14.3.1.7 | Soldaduras | 7d | 2019-02-28 | 2019-03-08 | 87 | 91d |  |
| 91 | 14.3.2 | **MODULO 4** | 40d | 2019-02-28 | 2019-04-24 | 66 | 58d |  |
| 92 | 14.3.2.1 | Nivelación de pernos de anclaje | 3d | 2019-02-28 | 2019-03-04 | 57, 87 | 58d | 0d |
| 93 | 14.3.2.2 | Izado y Colocación de columnas | 5d | 2019-03-05 | 2019-03-11 | 92 | 58d | 0d |
| 94 | 14.3.2.3 | Ensamblaje Vigas Carga | 15d | 2019-03-07 | 2019-03-27 | 93SS+2d | 58d | 0d |
| 95 | 14.3.2.4 | Ensamblaje Vigas Auxiliares | 20d | 2019-03-14 | 2019-04-10 | 94SS+5d | 58d | 0d |
| 96 | 14.3.2.5 | Arriostramientos, Soportes | 7d | 2019-03-26 | 2019-04-03 | 95SS+8d | 73d |  |
| 97 | 14.3.2.6 | Ajustes | 10d | 2019-04-11 | 2019-04-24 | 95 | 58d |  |
| 98 | 14.3.2.7 | Soldaduras | 7d | 2019-04-11 | 2019-04-19 | 95 | 61d |  |

| ID | WBS | Task | Duration | Start | Finish | Predecessors | Total slack | Free slack | Constraint |
| --- | --- | --- | --- | --- | --- | --- | --- | --- | --- |
| 99 | 14.3.3 | **MODULO 5** | 14d | 2019-04-11 | 2019-04-30 | 70 | 3d |  |  |
| 100 | 14.3.3.1 | Nivelación de pernos de anclaje | 1d | 2019-04-11 | 2019-04-11 | 57, 95 | 65d | 0d | finish no earlier than 2019-01-10 |
| 101 | 14.3.3.2 | Izado y Colocación de columnas | 2d | 2019-04-12 | 2019-04-15 | 100 | 65d | 0d | finish no earlier than 2019-01-17 |
| 102 | 14.3.3.3 | Ensamblaje Vigas Carga | 5d | 2019-04-16 | 2019-04-22 | 101SS+2d | 0d |  | finish no earlier than 2019-02-04 |
| 103 | 14.3.3.4 | Ensamblaje Vigas Auxiliares | 5d | 2019-04-19 | 2019-04-25 | 102SS+3d | 54d | 0d | finish no earlier than 2019-02-11 |
| 104 | 14.3.3.5 | Ajustes | 3d | 2019-04-26 | 2019-04-30 | 103 | 54d |  | finish no earlier than 2019-02-25 |
| 105 | 14.3.4 | **MODULO 1** | 40d | 2019-04-23 | 2019-06-17 | 74 | 0d |  |  |
| 106 | 14.3.4.1 | Nivelación de pernos de anclaje | 3d | 2019-04-23 | 2019-04-25 | 57, 102 | 0d |  |  |
| 107 | 14.3.4.2 | Izado y Colocación de columnas | 5d | 2019-04-26 | 2019-05-02 | 106 | 0d |  |  |
| 108 | 14.3.4.3 | Ensamblaje Vigas Carga | 15d | 2019-04-30 | 2019-05-20 | 107SS+2d | 0d |  |  |
| 109 | 14.3.4.4 | Ensamblaje Vigas Auxiliares | 20d | 2019-05-07 | 2019-06-03 | 108SS+5d | 20d | 0d |  |
| 110 | 14.3.4.5 | Arriostramientos, Soportes | 7d | 2019-05-17 | 2019-05-27 | 109SS+8d | 35d |  |  |
| 111 | 14.3.4.6 | Ajustes | 10d | 2019-06-04 | 2019-06-17 | 109 | 20d |  |  |
| 112 | 14.3.4.7 | Soldaduras | 7d | 2019-06-04 | 2019-06-12 | 109 | 23d |  |  |
| 113 | 14.3.5 | **MODULO 2** | 40d | 2019-05-21 | 2019-07-15 | 78 | 0d |  |  |
| 114 | 14.3.5.1 | Nivelación de pernos de anclaje | 3d | 2019-05-21 | 2019-05-23 | 57, 108 | 0d |  |  |
| 115 | 14.3.5.2 | Izado y Colocación de columnas | 5d | 2019-05-24 | 2019-05-30 | 114 | 0d |  |  |
| 116 | 14.3.5.3 | Ensamblaje Vigas Carga | 15d | 2019-05-28 | 2019-06-17 | 115SS+2d | 0d |  |  |
| 117 | 14.3.5.4 | Ensamblaje Vigas Auxiliares | 20d | 2019-06-04 | 2019-07-01 | 116SS+5d | 0d |  |  |
| 118 | 14.3.5.5 | Arriostramientos, Soportes | 7d | 2019-06-14 | 2019-06-24 | 117SS+8d | 15d |  |  |
| 119 | 14.3.5.6 | Ajustes | 10d | 2019-07-02 | 2019-07-15 | 117 | 0d |  |  |
| 120 | 14.3.5.7 | Soldaduras | 7d | 2019-07-02 | 2019-07-10 | 117 | 3d |  |  |
| 121 | 14.4 | **Cierre** | 8d | 2019-07-16 | 2019-07-25 |  | 0d |  |  |
| 122 | 14.4.1 | Informes de Calidad Ensamblaje | 1d | 2019-07-16 | 2019-07-16 | 82 | 0d |  |  |
| 123 | 14.4.2 | Recogida y Traslado de Gruas | 7d | 2019-07-17 | 2019-07-25 | 82, 122 | 8d |  |  |
| 124 | 14.4.3 | Recogida y Traslado de Maquinarias y Equipos | 5d | 2019-07-17 | 2019-07-23 | 82, 122 | 10d |  |  |
| 125 | 14.4.4 | Recogida y Traslado de Oficinas | 5d | 2019-07-16 | 2019-07-22 | 82 | 11d |  |  |
